Schedule from MS Project, 2002-01-28 to 2002-06-06, status date 2002-02-07, A marks actual dates.

## Calendars

- Working Calendar: Mon 08:00-12:00, 13:00-17:00; Tue-Wed off; Thu 08:00-12:00, 13:00-17:00; Fri-Sun off. Exceptions (off unless hours are given): 2002-01-28 08:00-12:00, 13:00-17:00, 2002-01-29 to 2002-01-30, 2002-02-01, 2002-02-05 to 2002-02-06, 2002-03-15 08:00-12:00, 13:00-17:00, 2002-03-22 to 2002-03-29, 2002-04-01 to 2002-04-12.

## Resources

| Resource |
| --- |
| Chris |
| Trevor |
| Hakim |
| Jimmy |
| Sami |
| William |
| Stuart |

## Schedule

| ID | WBS | Task | Duration | Start | Finish | Complete | Remaining | Baseline start | Baseline finish | Baseline duration | Total slack | Constraint | Resources | Work | Actual work |
| --- | --- | --- | --- | --- | --- | --- | --- | --- | --- | --- | --- | --- | --- | --- | --- |
| 1 | 1 | **Full Project** | 32.12d | 2002-01-28 08:00 A | 2002-06-06 09:00 | 43% | 18.45d | 2002-01-28 08:00 | 2002-06-06 09:00 | 32.12d | 0d |  | Chris; Trevor; Hakim; Jimmy; Sami; William; Stuart | 7123.75h | 4214.72h |
| 2 | 1.1 | **Progress Monitoring** | 31.12d | 2002-01-31 08:00 A | 2002-06-06 09:00 A | 100% |  | 2002-01-31 08:00 | 2002-06-06 09:00 | 31.12d |  |  |  | 2127h | 2127h |
| 3 | 1.1.1 | **Work review** | 29.25d | 2002-01-31 08:00 A | 2002-05-30 10:00 A | 100% |  | 2002-01-31 08:00 | 2002-05-30 10:00 | 29.25d |  |  | Chris; Trevor; Hakim; Jimmy; Sami; William; Stuart | 1862h | 1862h |
| 4 | 1.1.1.1 | Work review 1 | 2h | 2002-01-31 08:00 A | 2002-01-31 10:00 A | 100% |  | 2002-01-31 08:00 | 2002-01-31 10:00 | 2h |  |  | Chris; Trevor; Hakim; Jimmy; Sami; William; Stuart | 14h | 14h |
| 5 | 1.1.1.2 | Work review 2 | 2h | 2002-02-07 08:00 A | 2002-02-07 10:00 A | 100% |  | 2002-02-07 08:00 | 2002-02-07 10:00 | 2h |  |  | Chris; Trevor; Hakim; Jimmy; Sami; William; Stuart | 14h | 14h |
| 6 | 1.1.1.3 | Work review 3 | 2h | 2002-02-14 08:00 A | 2002-02-14 10:00 A | 100% |  | 2002-02-14 08:00 | 2002-02-14 10:00 | 2h |  |  | Chris; Trevor; Hakim; Jimmy; Sami; William; Stuart | 14h | 14h |
| 7 | 1.1.1.4 | Work review 4 | 2h | 2002-02-21 08:00 A | 2002-02-21 10:00 A | 100% |  | 2002-02-21 08:00 | 2002-02-21 10:00 | 2h |  |  | Chris; Trevor; Hakim; Jimmy; Sami; William; Stuart | 14h | 14h |
| 8 | 1.1.1.5 | Work review 5 | 2h | 2002-02-28 08:00 A | 2002-02-28 10:00 A | 100% |  | 2002-02-28 08:00 | 2002-02-28 10:00 | 2h |  |  | Chris; Trevor; Hakim; Jimmy; Sami; William; Stuart | 14h | 14h |
| 9 | 1.1.1.6 | Work review 6 | 2h | 2002-03-07 08:00 A | 2002-03-07 10:00 A | 100% |  | 2002-03-07 08:00 | 2002-03-07 10:00 | 2h |  |  | Chris; Trevor; Hakim; Jimmy; Sami; William; Stuart | 14h | 14h |
| 10 | 1.1.1.7 | Work review 7 | 2h | 2002-03-14 08:00 A | 2002-03-14 10:00 A | 100% |  | 2002-03-14 08:00 | 2002-03-14 10:00 | 2h |  |  | Chris; Trevor; Hakim; Jimmy; Sami; William; Stuart | 14h | 14h |
| 11 | 1.1.1.8 | Work review 8 | 2h | 2002-03-21 08:00 A | 2002-03-21 10:00 A | 100% |  | 2002-03-21 08:00 | 2002-03-21 10:00 | 2h |  |  | Chris; Trevor; Hakim; Jimmy; Sami; William; Stuart | 14h | 14h |
| 12 | 1.1.1.9 | Work review 9 | 2h | 2002-03-28 08:00 A | 2002-04-15 10:00 A | 100% |  | 2002-03-28 08:00 | 2002-04-15 10:00 | 2h |  |  | Chris; Trevor; Hakim; Jimmy; Sami; William; Stuart | 14h | 14h |
| 13 | 1.1.1.10 | Work review 10 | 2h | 2002-04-18 08:00 A | 2002-04-18 10:00 A | 100% |  | 2002-04-18 08:00 | 2002-04-18 10:00 | 2h |  |  | Chris; Trevor; Hakim; Jimmy; Sami; William; Stuart | 14h | 14h |
| 14 | 1.1.1.11 | Work review 11 | 2h | 2002-04-25 08:00 A | 2002-04-25 10:00 A | 100% |  | 2002-04-25 08:00 | 2002-04-25 10:00 | 2h |  |  | Chris; Trevor; Hakim; Jimmy; Sami; William; Stuart | 14h | 14h |
| 15 | 1.1.1.12 | Work review 12 | 2h | 2002-05-02 08:00 A | 2002-05-02 10:00 A | 100% |  | 2002-05-02 08:00 | 2002-05-02 10:00 | 2h |  |  | Chris; Trevor; Hakim; Jimmy; Sami; William; Stuart | 14h | 14h |
| 16 | 1.1.1.13 | Work review 13 | 2h | 2002-05-09 08:00 A | 2002-05-09 10:00 A | 100% |  | 2002-05-09 08:00 | 2002-05-09 10:00 | 2h |  |  | Chris; Trevor; Hakim; Jimmy; Sami; William; Stuart | 14h | 14h |
| 17 | 1.1.1.14 | Work review 14 | 2h | 2002-05-16 08:00 A | 2002-05-16 10:00 A | 100% |  | 2002-05-16 08:00 | 2002-05-16 10:00 | 2h |  |  | Chris; Trevor; Hakim; Jimmy; Sami; William; Stuart | 14h | 14h |
| 18 | 1.1.1.15 | Work review 15 | 2h | 2002-05-23 08:00 A | 2002-05-23 10:00 A | 100% |  | 2002-05-23 08:00 | 2002-05-23 10:00 | 2h |  |  | Chris; Trevor; Hakim; Jimmy; Sami; William; Stuart | 14h | 14h |
| 19 | 1.1.1.16 | Work review 16 | 2h | 2002-05-30 08:00 A | 2002-05-30 10:00 A | 100% |  | 2002-05-30 08:00 | 2002-05-30 10:00 | 2h |  | start no earlier than 2002-06-06 08:00 | Chris; Trevor; Hakim; Jimmy; Sami; William; Stuart | 14h | 14h |
| 20 | 1.1.2 | **Plan Update** | 31.12d | 2002-01-31 08:00 A | 2002-06-06 09:00 A | 100% |  | 2002-01-31 08:00 | 2002-06-06 09:00 | 31.12d |  |  | Hakim | 265h | 265h |
| 21 | 1.1.2.1 | Plan Update 1 | 1h | 2002-01-31 08:00 A | 2002-01-31 09:00 A | 100% |  | 2002-01-31 08:00 | 2002-01-31 09:00 | 1h |  |  | Hakim | 1h | 1h |
| 22 | 1.1.2.2 | Plan Update 2 | 1h | 2002-02-07 08:00 A | 2002-02-07 09:00 A | 100% |  | 2002-02-07 08:00 | 2002-02-07 09:00 | 1h |  |  | Hakim | 1h | 1h |
| 23 | 1.1.2.3 | Plan Update 3 | 1h | 2002-02-14 08:00 A | 2002-02-14 09:00 A | 100% |  | 2002-02-14 08:00 | 2002-02-14 09:00 | 1h |  |  | Hakim | 1h | 1h |
| 24 | 1.1.2.4 | Plan Update 4 | 1h | 2002-02-21 08:00 A | 2002-02-21 09:00 A | 100% |  | 2002-02-21 08:00 | 2002-02-21 09:00 | 1h |  |  | Hakim | 1h | 1h |
| 25 | 1.1.2.5 | Plan Update 5 | 1h | 2002-02-28 08:00 A | 2002-02-28 09:00 A | 100% |  | 2002-02-28 08:00 | 2002-02-28 09:00 | 1h |  |  | Hakim | 1h | 1h |
| 26 | 1.1.2.6 | Plan Update 6 | 1h | 2002-03-07 08:00 A | 2002-03-07 09:00 A | 100% |  | 2002-03-07 08:00 | 2002-03-07 09:00 | 1h |  |  | Hakim | 1h | 1h |
| 27 | 1.1.2.7 | Plan Update 7 | 1h | 2002-03-14 08:00 A | 2002-03-14 09:00 A | 100% |  | 2002-03-14 08:00 | 2002-03-14 09:00 | 1h |  |  | Hakim | 1h | 1h |
| 28 | 1.1.2.8 | Plan Update 8 | 1h | 2002-03-21 08:00 A | 2002-03-21 09:00 A | 100% |  | 2002-03-21 08:00 | 2002-03-21 09:00 | 1h |  |  | Chris | 1h | 1h |
| 29 | 1.1.2.9 | Plan Update 9 | 1h | 2002-04-18 08:00 A | 2002-04-18 09:00 A | 100% |  | 2002-04-18 08:00 | 2002-04-18 09:00 | 1h |  |  | Hakim | 1h | 1h |
| 30 | 1.1.2.10 | Plan Update 10 | 1h | 2002-04-25 08:00 A | 2002-04-25 09:00 A | 100% |  | 2002-04-25 08:00 | 2002-04-25 09:00 | 1h |  |  | Hakim | 1h | 1h |
| 31 | 1.1.2.11 | Plan Update 11 | 1h | 2002-05-02 08:00 A | 2002-05-02 09:00 A | 100% |  | 2002-05-02 08:00 | 2002-05-02 09:00 | 1h |  |  | Hakim | 1h | 1h |
| 32 | 1.1.2.12 | Plan Update 12 | 1h | 2002-05-09 08:00 A | 2002-05-09 09:00 A | 100% |  | 2002-05-09 08:00 | 2002-05-09 09:00 | 1h |  |  | Hakim | 1h | 1h |
| 33 | 1.1.2.13 | Plan Update 13 | 1h | 2002-05-16 08:00 A | 2002-05-16 09:00 A | 100% |  | 2002-05-16 08:00 | 2002-05-16 09:00 | 1h |  |  | Hakim | 1h | 1h |
| 34 | 1.1.2.14 | Plan Update 14 | 1h | 2002-05-23 08:00 A | 2002-05-23 09:00 A | 100% |  | 2002-05-23 08:00 | 2002-05-23 09:00 | 1h |  |  | Hakim | 1h | 1h |
| 35 | 1.1.2.15 | Plan Update 15 | 1h | 2002-05-30 08:00 A | 2002-05-30 09:00 A | 100% |  | 2002-05-30 08:00 | 2002-05-30 09:00 | 1h |  |  | Hakim | 1h | 1h |
| 36 | 1.1.2.16 | Plan Update 16 | 1h | 2002-06-06 08:00 A | 2002-06-06 09:00 A | 100% |  | 2002-06-06 08:00 | 2002-06-06 09:00 | 1h |  |  | Hakim | 1h | 1h |

| ID | WBS | Task | Duration | Start | Finish | Predecessors | Complete | Remaining | Baseline start | Baseline finish | Baseline duration | Total slack | Constraint | Resources | Work | Actual work |
| --- | --- | --- | --- | --- | --- | --- | --- | --- | --- | --- | --- | --- | --- | --- | --- | --- |
| 37 | 1.2 | **First Stage** | 9.25d | 2002-01-28 08:00 A | 2002-02-28 10:00 |  | 87% | 1.22d | 2002-01-28 08:00 | 2002-02-28 10:00 | 9.25d | 22.88d |  |  | 1229.75h | 1042.11h |
| 38 | 1.2.1 | **Background** | 9.25d | 2002-01-28 08:00 A | 2002-02-28 10:00 |  | 84% | 1.43d | 2002-01-28 08:00 | 2002-02-28 10:00 | 9.25d | 22.88d |  |  | 346h | 247.7h |
| 39 | 1.2.1.1 | **Work Plan** | 5d | 2002-01-28 08:00 A | 2002-02-11 17:00 A |  | 100% |  | 2002-01-28 08:00 | 2002-02-11 17:00 | 5d |  |  |  | 44h | 44h |
| 40 | 1.2.1.1.1 | Work break down | 8h | 2002-01-28 08:00 A | 2002-01-28 17:00 A |  | 100% |  | 2002-01-28 08:00 | 2002-01-28 17:00 | 8h |  | start no earlier than 2002-01-28 08:00 | Trevor; Hakim | 16h | 16h |
| 41 | 1.2.1.1.2 | Time allocation | 4h | 2002-02-04 08:00 A | 2002-02-04 12:00 A | 40 | 100% |  | 2002-02-04 08:00 | 2002-02-04 12:00 | 4h |  | start no earlier than 2002-02-04 08:00 | Trevor [50%]; Hakim | 6h | 6h |
| 42 | 1.2.1.1.3 | Learn MS Project | 6h | 2002-02-07 08:00 A | 2002-02-07 15:00 A |  | 100% |  | 2002-02-07 08:00 | 2002-02-07 15:00 | 6h |  | start no earlier than 2002-02-07 08:00 | Trevor [33%]; Hakim [67%] | 6h | 6h |
| 43 | 1.2.1.1.4 | Resource allocation | 8h | 2002-02-07 08:00 A | 2002-02-07 17:00 A | 41 | 100% |  | 2002-02-07 08:00 | 2002-02-07 17:00 | 8h |  | start no earlier than 2002-02-07 08:00 | Hakim | 8h | 8h |
| 44 | 1.2.1.1.5 | Documentation | 8h | 2002-02-11 08:00 A | 2002-02-11 17:00 A | 41 | 100% |  | 2002-02-11 08:00 | 2002-02-11 17:00 | 8h |  | finish no earlier than 2002-02-14 17:00 | Hakim | 8h | 8h |
| 45 | 1.2.1.2 | **DLL** | 6d | 2002-01-28 08:00 A | 2002-02-14 17:00 |  | 67% | 2d | 2002-01-28 08:00 | 2002-02-14 17:00 | 6d | 26.12d |  | Trevor | 40h | 12h |
| 46 | 1.2.1.2.1 | Research | 8h | 2002-01-28 08:00 A | 2002-01-28 17:00 A |  | 100% |  | 2002-01-28 08:00 | 2002-01-28 17:00 | 8h |  |  |  |  |  |
| 47 | 1.2.1.2.2 | Report write up | 4h | 2002-02-14 13:00 | 2002-02-14 17:00 |  |  |  | 2002-02-14 13:00 | 2002-02-14 17:00 | 4h | 26.12d | finish no earlier than 2002-02-14 17:00 |  |  |  |
| 48 | 1.2.1.3 | **GNU Makefile** | 7.5d | 2002-01-28 08:00 A | 2002-02-21 12:00 |  | 67% | 2.5d | 2002-01-28 08:00 | 2002-02-21 12:00 | 7.5d | 24.62d |  | Hakim | 52h | 12h |
| 49 | 1.2.1.3.1 | Research | 8h | 2002-01-28 08:00 A | 2002-01-28 17:00 A |  | 100% |  | 2002-01-28 08:00 | 2002-01-28 17:00 | 8h |  | start no earlier than 2002-01-31 08:00 |  |  |  |
| 50 | 1.2.1.3.2 | Report Write ups | 4h | 2002-02-21 08:00 | 2002-02-21 12:00 |  |  |  | 2002-02-21 08:00 | 2002-02-21 12:00 | 4h | 24.62d | start no earlier than 2002-02-21 08:00 |  |  |  |
| 51 | 1.2.1.4 | **Handle-C Learning** | 9.25d | 2002-01-28 08:00 A | 2002-02-28 10:00 A |  | 100% |  | 2002-01-28 08:00 | 2002-02-28 10:00 | 9.25d |  |  |  | 158h | 158h |
| 52 | 1.2.1.4.1 | CBT | 14h | 2002-02-14 08:00 A | 2002-02-18 15:00 A |  | 50% |  | 2002-02-14 08:00 | 2002-02-18 15:00 | 14h |  |  | Trevor; Hakim; Sami; William; Jimmy; Stuart | 84h | 84h |
| 53 | 1.2.1.4.2 | Specialise | 74h | 2002-01-28 08:00 A | 2002-02-28 10:00 A |  | 90% |  | 2002-01-28 08:00 | 2002-02-28 10:00 | 74h |  | start no earlier than 2002-01-28 08:00 | Chris | 74h | 74h |
| 54 | 1.2.1.5 | GCC / Cygwin Learning | 16h | 2002-01-28 08:00 | 2002-01-31 17:00 |  |  |  | 2002-01-28 08:00 | 2002-01-31 17:00 | 16h | 30.12d |  | William [80%]; Sami [70%] | 24h |  |
| 55 | 1.2.1.6 | **Test Plan** | 3.5d | 2002-01-31 08:00 A | 2002-02-11 12:00 |  | 78% | 0.79d | 2002-01-31 08:00 | 2002-02-11 12:00 | 3.5d | 27.62d |  | Jimmy | 28h | 21.7h |
| 56 | 1.2.1.6.1 | Research | 12h | 2002-01-31 08:00 A | 2002-02-04 12:00 A |  | 100% |  | 2002-01-31 08:00 | 2002-02-04 12:00 | 12h |  | start no earlier than 2002-01-31 08:00 |  |  |  |
| 57 | 1.2.1.6.2 | Writing up | 4h | 2002-02-11 08:00 A | 2002-02-11 12:00 |  | 10% | 3.6h | 2002-02-11 08:00 | 2002-02-11 12:00 | 4h | 27.62d | start no earlier than 2002-02-11 08:00 |  |  |  |
| 58 | 1.2.2 | **Software only prototype** | 6d | 2002-01-28 08:00 A | 2002-02-14 17:00 A |  | 100% |  | 2002-01-28 08:00 | 2002-02-14 17:00 | 6d |  |  |  | 120h | 120h |
| 59 | 1.2.2.1 | Integration Plan | 4h | 2002-01-28 08:00 A | 2002-01-28 12:00 A |  | 100% |  | 2002-01-28 08:00 | 2002-01-28 12:00 | 4h |  |  | Sami [50%]; William [50%] | 4h | 4h |
| 60 | 1.2.2.2 | **System call ID** | 2d | 2002-01-28 08:00 A | 2002-01-31 17:00 A |  | 100% |  | 2002-01-28 08:00 | 2002-01-31 17:00 | 2d |  |  |  | 32h | 32h |
| 61 | 1.2.2.2.1 | Lame | 16h | 2002-01-28 08:00 A | 2002-01-31 17:00 A |  | 100% |  | 2002-01-28 08:00 | 2002-01-31 17:00 | 16h |  |  | Sami | 16h | 16h |
| 62 | 1.2.2.2.2 | PGP | 16h | 2002-01-28 08:00 A | 2002-01-31 17:00 A |  | 100% |  | 2002-01-28 08:00 | 2002-01-31 17:00 | 16h |  |  | William | 16h | 16h |

| ID | WBS | Task | Duration | Start | Finish | Predecessors | Complete | Baseline start | Baseline finish | Baseline duration | Constraint | Resources | Work | Actual work |
| --- | --- | --- | --- | --- | --- | --- | --- | --- | --- | --- | --- | --- | --- | --- |
| 63 | 1.2.2.3 | **System Call Removal** | 2d | 2002-02-04 08:00 A | 2002-02-07 17:00 A |  | 100% | 2002-02-04 08:00 | 2002-02-07 17:00 | 2d |  |  | 32h | 32h |
| 64 | 1.2.2.3.1 | Lame | 16h | 2002-02-04 08:00 A | 2002-02-07 17:00 A | 61 | 100% | 2002-02-04 08:00 | 2002-02-07 17:00 | 16h |  | Sami | 16h | 16h |
| 65 | 1.2.2.3.2 | PGP | 16h | 2002-02-04 08:00 A | 2002-02-07 17:00 A | 62 | 100% | 2002-02-04 08:00 | 2002-02-07 17:00 | 16h | start no earlier than 2002-02-04 08:00 | William | 16h | 16h |
| 66 | 1.2.2.4 | **System Integration** | 1.25d | 2002-02-11 08:00 A | 2002-02-14 10:00 A |  | 100% | 2002-02-11 08:00 | 2002-02-14 10:00 | 1.25d |  | Sami; William | 36h | 36h |
| 67 | 1.2.2.4.1 | I/O Module design | 6h | 2002-02-11 10:00 A | 2002-02-11 17:00 A |  | 100% | 2002-02-11 10:00 | 2002-02-11 17:00 | 6h |  | Sami [50%]; William [50%] | 6h | 6h |
| 68 | 1.2.2.4.2 | Implementation & Testing | 10h | 2002-02-11 08:00 A | 2002-02-14 10:00 A | 67 | 100% | 2002-02-11 08:00 | 2002-02-14 10:00 | 10h | start no earlier than 2002-02-11 08:00 | Sami [50%]; William [50%] | 10h | 10h |
| 69 | 1.2.2.5 | System testing | 8h | 2002-02-14 08:00 A | 2002-02-14 17:00 A |  | 100% | 2002-02-14 08:00 | 2002-02-14 17:00 | 8h |  | Sami [50%]; William [50%] | 8h | 8h |
| 70 | 1.2.2.6 | Required changes | 8h | 2002-02-14 08:00 A | 2002-02-14 17:00 A |  | 100% | 2002-02-14 08:00 | 2002-02-14 17:00 | 8h | finish no earlier than 2002-02-14 17:00 | Sami | 8h | 8h |
| 71 | 1.2.3 | **Profiling** | 7.12d | 2002-01-28 08:00 A | 2002-02-21 09:00 A |  | 100% | 2002-01-28 08:00 | 2002-02-21 09:00 | 7.12d |  | Sami; William | 328h | 328h |
| 72 | 1.2.3.1 | **Encoder** | 0.38d | 2002-01-28 08:00 A | 2002-01-28 11:00 A |  | 100% | 2002-01-28 08:00 | 2002-01-28 11:00 | 0.38d |  | Sami | 3h | 3h |
| 73 | 1.2.3.1.1 | Analysis | 2h | 2002-01-28 08:00 A | 2002-01-28 10:00 A |  | 100% | 2002-01-28 08:00 | 2002-01-28 10:00 | 2h |  |  |  |  |
| 74 | 1.2.3.1.2 | Documentation | 3h | 2002-01-28 08:00 A | 2002-01-28 11:00 A |  | 100% | 2002-01-28 08:00 | 2002-01-28 11:00 | 3h |  |  |  |  |
| 75 | 1.2.3.2 | **Decoder** | 6.38d | 2002-01-28 08:00 A | 2002-02-18 11:00 A |  | 100% | 2002-01-28 08:00 | 2002-02-18 11:00 | 6.38d |  | Sami | 51h | 51h |
| 76 | 1.2.3.2.1 | Analysis | 2h | 2002-01-28 08:00 A | 2002-01-28 10:00 A |  | 100% | 2002-01-28 08:00 | 2002-01-28 10:00 | 2h |  |  |  |  |
| 77 | 1.2.3.2.2 | Documentation | 3h | 2002-02-18 08:00 A | 2002-02-18 11:00 A |  | 100% | 2002-02-18 08:00 | 2002-02-18 11:00 | 3h | start no earlier than 2002-02-18 08:00 |  |  |  |
| 78 | 1.2.3.3 | **Encryption** | 6.38d | 2002-01-28 08:00 A | 2002-02-18 11:00 A |  | 100% | 2002-01-28 08:00 | 2002-02-18 11:00 | 6.38d |  | William | 51h | 51h |
| 79 | 1.2.3.3.1 | Analysis | 2h | 2002-01-28 08:00 A | 2002-01-28 10:00 A |  | 100% | 2002-01-28 08:00 | 2002-01-28 10:00 | 2h |  |  |  |  |
| 80 | 1.2.3.3.2 | Documentation | 3h | 2002-02-18 08:00 A | 2002-02-18 11:00 A |  | 100% | 2002-02-18 08:00 | 2002-02-18 11:00 | 3h | start no earlier than 2002-02-18 08:00 |  |  |  |
| 81 | 1.2.3.4 | **Decryption** | 6.38d | 2002-01-28 08:00 A | 2002-02-18 11:00 A |  | 100% | 2002-01-28 08:00 | 2002-02-18 11:00 | 6.38d |  | William | 51h | 51h |
| 82 | 1.2.3.4.1 | Analysis | 2h | 2002-01-28 08:00 A | 2002-01-28 10:00 A |  | 100% | 2002-01-28 08:00 | 2002-01-28 10:00 | 2h |  |  |  |  |
| 83 | 1.2.3.4.2 | Documentation | 3h | 2002-02-18 08:00 A | 2002-02-18 11:00 A |  | 100% | 2002-02-18 08:00 | 2002-02-18 11:00 | 3h | start no earlier than 2002-02-18 08:00 |  |  |  |
| 84 | 1.2.3.5 | **Over All Encoding/Encryption** | 7.12d | 2002-01-28 08:00 A | 2002-02-21 09:00 A |  | 100% | 2002-01-28 08:00 | 2002-02-21 09:00 | 7.12d |  | Sami | 57h | 57h |
| 85 | 1.2.3.5.1 | Analysis | 1h | 2002-01-28 08:00 A | 2002-01-28 09:00 A |  | 100% | 2002-01-28 08:00 | 2002-01-28 09:00 | 1h |  |  |  |  |
| 86 | 1.2.3.5.2 | Documentation | 1h | 2002-02-21 08:00 A | 2002-02-21 09:00 A |  | 100% | 2002-02-21 08:00 | 2002-02-21 09:00 | 1h | start no earlier than 2002-02-21 08:00 |  |  |  |

| ID | WBS | Task | Duration | Start | Finish | Predecessors | Complete | Remaining | Baseline start | Baseline finish | Baseline duration | Total slack | Free slack | Constraint | Resources | Work | Actual work |
| --- | --- | --- | --- | --- | --- | --- | --- | --- | --- | --- | --- | --- | --- | --- | --- | --- | --- |
| 87 | 1.2.3.6 | **Over All Decoding/Decryption** | 0.12d | 2002-02-21 08:00 A | 2002-02-21 09:00 A |  | 100% |  | 2002-02-21 08:00 | 2002-02-21 09:00 | 0.12d |  |  |  | William | 1h | 1h |
| 88 | 1.2.3.6.1 | Analysis | 1h | 2002-02-21 08:00 A | 2002-02-21 09:00 A |  | 100% |  | 2002-02-21 08:00 | 2002-02-21 09:00 | 1h |  |  | start no earlier than 2002-02-21 08:00 |  |  |  |
| 89 | 1.2.3.6.2 | Documentation | 1h | 2002-02-21 08:00 A | 2002-02-21 09:00 A |  | 100% |  | 2002-02-21 08:00 | 2002-02-21 09:00 | 1h |  |  | start no earlier than 2002-02-21 08:00 |  |  |  |
| 90 | 1.2.4 | **ASIP Prototype** | 7.62d | 2002-01-28 08:00 A | 2002-02-21 14:00 |  | 71% | 2.24d | 2002-01-28 08:00 | 2002-02-21 14:00 | 7.62d | 24.5d |  |  | Stuart; Trevor | 316h | 226.66h |
| 91 | 1.2.4.1 | **MIPS Emulator** | 5.62d | 2002-01-28 08:00 A | 2002-02-14 14:00 A |  | 100% |  | 2002-01-28 08:00 | 2002-02-14 14:00 | 5.62d |  |  |  |  | 58h | 58h |
| 92 | 1.2.4.1.1 | Write & run program on SPIM | 12h | 2002-01-28 08:00 A | 2002-01-31 12:00 A |  | 100% |  | 2002-01-28 08:00 | 2002-01-31 12:00 | 12h |  |  |  | Stuart | 12h | 12h |
| 93 | 1.2.4.1.2 | Produce Object code & Test/Validate | 12h | 2002-01-31 08:00 A | 2002-02-04 12:00 A |  | 100% |  | 2002-01-31 08:00 | 2002-02-04 12:00 | 12h |  |  |  | Stuart | 12h | 12h |
| 94 | 1.2.4.1.3 | Produce executable & Validate/Test | 12h | 2002-02-04 08:00 A | 2002-02-07 12:00 A |  | 100% |  | 2002-02-04 08:00 | 2002-02-07 12:00 | 12h |  |  |  | Stuart; Trevor | 24h | 24h |
| 95 | 1.2.4.1.4 | Document | 5h | 2002-02-14 08:00 A | 2002-02-14 14:00 A |  | 100% |  | 2002-02-14 08:00 | 2002-02-14 14:00 | 5h |  |  | start no earlier than 2002-02-14 08:00 | Stuart; Trevor | 10h | 10h |
| 96 | 1.2.4.2 | **ASIP PROCESSOR** | 3.62d | 2002-02-11 08:00 A | 2002-02-21 14:00 |  | 39% | 2.22d | 2002-02-11 08:00 | 2002-02-21 14:00 | 3.62d | 24.5d |  |  | Stuart; Trevor | 78h | 42.41h |
| 97 | 1.2.4.2.1 | Write ASIP Processor | 20h | 2002-02-11 08:00 A | 2002-02-18 12:00 | 95 | 40% | 12h | 2002-02-11 08:00 | 2002-02-18 12:00 | 20h | 25.62d | 0d |  | Stuart | 20h | 20h |
| 98 | 1.2.4.2.2 | Test and modify | 12h | 2002-02-14 08:00 A | 2002-02-18 12:00 | 97FF | 40% | 7.2h | 2002-02-14 08:00 | 2002-02-18 12:00 | 12h | 25.62d |  | finish no earlier than 2002-02-18 17:00 |  |  |  |
| 99 | 1.2.4.2.3 | Document | 5h | 2002-02-21 08:00 A | 2002-02-21 14:00 |  | 30% | 3.5h | 2002-02-21 08:00 | 2002-02-21 14:00 | 5h | 24.5d |  | start no earlier than 2002-02-21 08:00 |  |  |  |
| 100 | 1.2.4.3 | **Static analysis Of Application** | 7.25d | 2002-01-28 08:00 A | 2002-02-21 10:00 |  | 69% | 2.25d | 2002-01-28 08:00 | 2002-02-21 10:00 | 7.25d | 24.88d |  |  | Trevor | 58h | 40.02h |
| 101 | 1.2.4.3.1 | Compile for MIPS | 2h | 2002-01-28 08:00 A | 2002-01-28 10:00 |  | 75% | 0.5h | 2002-01-28 08:00 | 2002-01-28 10:00 | 2h | 31.88d |  |  |  |  |  |
| 102 | 1.2.4.3.2 | Select Hotspots | 4h | 2002-01-28 08:00 A | 2002-01-28 12:00 A |  | 100% |  | 2002-01-28 08:00 | 2002-01-28 12:00 | 4h |  |  |  |  |  |  |
| 103 | 1.2.4.3.3 | Get Register count | 1h | 2002-01-28 08:00 | 2002-01-28 09:00 |  |  |  | 2002-01-28 08:00 | 2002-01-28 09:00 | 1h | 32d |  |  |  |  |  |
| 104 | 1.2.4.3.4 | Get Instruction Count | 1h | 2002-01-28 08:00 A | 2002-01-28 09:00 A |  | 100% |  | 2002-01-28 08:00 | 2002-01-28 09:00 | 1h |  |  |  |  |  |  |
| 105 | 1.2.4.3.5 | Document | 2h | 2002-02-21 08:00 A | 2002-02-21 10:00 |  | 20% | 1.6h | 2002-02-21 08:00 | 2002-02-21 10:00 | 2h | 24.88d |  | start no earlier than 2002-02-21 08:00 |  |  |  |
| 106 | 1.2.5 | **Documentation** | 8.38d | 2002-01-28 08:00 A | 2002-02-25 11:00 A |  | 100% |  | 2002-01-28 08:00 | 2002-02-25 11:00 | 8.38d |  |  |  | Hakim | 102h | 102h |
| 107 | 1.2.5.1 | Compile documents | 4h | 2002-01-28 08:00 A | 2002-01-28 12:00 A |  | 100% |  | 2002-01-28 08:00 | 2002-01-28 12:00 | 4h |  |  |  | Hakim | 4h | 4h |
| 108 | 1.2.5.2 | Proof Read | 2h | 2002-01-28 08:00 A | 2002-01-28 10:00 A |  | 100% |  | 2002-01-28 08:00 | 2002-01-28 10:00 | 2h |  |  |  | Trevor; Sami; Chris; Hakim; William; Stuart; Jimmy | 14h | 14h |
| 109 | 1.2.5.3 | Discuss the changes | 2h | 2002-01-28 08:00 A | 2002-01-28 10:00 A |  | 100% |  | 2002-01-28 08:00 | 2002-01-28 10:00 | 2h |  |  |  | Trevor; Sami; Chris; Hakim; William; Stuart; Jimmy | 14h | 14h |
| 110 | 1.2.5.4 | Make Necessary changes | 3h | 2002-02-25 08:00 A | 2002-02-25 11:00 A |  | 100% |  | 2002-02-25 08:00 | 2002-02-25 11:00 | 3h |  |  | start no earlier than 2002-02-25 08:00 | Trevor | 3h | 3h |
| 111 | 1.2.6 | Formal Review with Board of directors | 0.25h | 2002-01-28 08:00 A | 2002-01-28 08:15 A |  | 100% |  | 2002-01-28 08:00 | 2002-01-28 08:15 | 0.25h |  |  |  | Trevor; Sami; Chris; Hakim; William; Stuart; Jimmy | 1.75h | 1.75h |
| 112 | 1.2.7 | Stage Review | 2h | 2002-01-28 08:00 A | 2002-01-28 10:00 A |  | 100% |  | 2002-01-28 08:00 | 2002-01-28 10:00 | 2h |  |  |  | Trevor; Sami; Hakim; William; Jimmy; Chris; Stuart | 14h | 14h |
| 113 | 1.2.8 | Change Plan if needed | 2h | 2002-01-28 08:00 A | 2002-01-28 10:00 A |  | 100% |  | 2002-01-28 08:00 | 2002-01-28 10:00 | 2h |  |  |  | Hakim | 2h | 2h |

| ID | WBS | Task | Duration | Start | Finish | Predecessors | Complete | Remaining | Baseline start | Baseline finish | Baseline duration | Total slack | Free slack | Constraint | Resources | Work | Actual work |
| --- | --- | --- | --- | --- | --- | --- | --- | --- | --- | --- | --- | --- | --- | --- | --- | --- | --- |
| 114 | 1.3 | **Second Stage** | 16.25d | 2002-01-28 08:00 A | 2002-03-21 10:00 |  | 33% | 10.83d | 2002-01-28 08:00 | 2002-03-21 10:00 | 16.25d | 15.88d |  |  |  | 787h | 279.82h |
| 115 | 1.3.1 | **Fixed Point Migration** | 8.25d | 2002-01-28 08:00 A | 2002-02-25 10:00 |  | 41% | 4.9d | 2002-01-28 08:00 | 2002-02-25 10:00 | 8.25d | 23.88d |  |  |  | 66h | 37.7h |
| 116 | 1.3.1.1 | Research and document | 8h | 2002-01-28 08:00 | 2002-01-28 17:00 |  |  |  | 2002-01-28 08:00 | 2002-01-28 17:00 | 8h | 31.12d |  |  | Trevor [65%]; Sami [35%] | 8h |  |
| 117 | 1.3.1.2 | **Convert to Fix point** | 7.25d | 2002-01-28 08:00 A | 2002-02-21 10:00 |  | 65% | 2.54d | 2002-01-28 08:00 | 2002-02-21 10:00 | 7.25d | 23.88d |  |  | Chris [20%]; Hakim [20%]; Jimmy [20%]; Sami [20%]; William [20%] | 58h | 37.7h |
| 118 | 1.3.1.2.1 | Lame Encoder | 10h | 2002-01-28 08:00 A | 2002-01-31 10:00 |  | 60% | 4h | 2002-01-28 08:00 | 2002-01-31 10:00 | 10h | 29.88d | 6d |  |  |  |  |
| 119 | 1.3.1.2.2 | Lame Decoder | 10h | 2002-01-28 08:00 | 2002-01-31 10:00 |  |  |  | 2002-01-28 08:00 | 2002-01-31 10:00 | 10h | 29.88d | 6d |  |  |  |  |
| 120 | 1.3.1.2.3 | PGP Encryption | 10h | 2002-01-28 08:00 A | 2002-01-31 10:00 A |  | 100% |  | 2002-01-28 08:00 | 2002-01-31 10:00 | 10h |  |  |  |  |  |  |
| 121 | 1.3.1.2.4 | PGP Decryption | 10h | 2002-02-18 08:00 A | 2002-02-21 10:00 A |  | 100% |  | 2002-02-18 08:00 | 2002-02-21 10:00 | 10h |  |  | start no earlier than 2002-02-18 08:00 |  |  |  |
| 122 | 1.3.1.3 | Testing | 8h | 2002-02-21 10:00 | 2002-02-25 10:00 | 118, 119, 120, 121 |  |  | 2002-02-21 10:00 | 2002-02-25 10:00 | 8h | 23.88d |  |  |  |  |  |
| 123 | 1.3.1.4 | Document | 8h | 2002-02-21 08:00 | 2002-02-21 17:00 |  |  |  | 2002-02-21 08:00 | 2002-02-21 17:00 | 8h | 24.12d |  | start no earlier than 2002-02-21 08:00 |  |  |  |
| 124 | 1.3.2 | **ASIP Prototype** | 12d | 2002-01-28 08:00 A | 2002-03-07 17:00 |  | 38% | 7.46d | 2002-01-28 08:00 | 2002-03-07 17:00 | 12d | 20.12d |  |  | Trevor; Stuart; Jimmy | 354h | 130.22h |
| 125 | 1.3.2.1 | **Interface Design** | 10.75d | 2002-01-28 08:00 | 2002-03-04 15:00 |  |  |  | 2002-01-28 08:00 | 2002-03-04 15:00 | 10.75d | 21.38d |  |  |  | 12h |  |
| 126 | 1.3.2.1.1 | Control | 6h | 2002-03-04 08:00 | 2002-03-04 15:00 |  |  |  | 2002-03-04 08:00 | 2002-03-04 15:00 | 6h | 21.38d |  | start no earlier than 2002-03-04 08:00 | Trevor | 6h |  |
| 127 | 1.3.2.1.2 | Communication | 6h | 2002-01-28 08:00 | 2002-01-28 15:00 |  |  |  | 2002-01-28 08:00 | 2002-01-28 15:00 | 6h | 31.38d |  |  | Trevor | 6h |  |
| 128 | 1.3.2.2 | Changes GCC Backend | 8h | 2002-01-28 08:00 A | 2002-01-28 17:00 A |  | 100% |  | 2002-01-28 08:00 | 2002-01-28 17:00 | 8h |  |  |  | Stuart | 8h | 8h |
| 129 | 1.3.2.3 | Test | 8h | 2002-01-28 13:00 A | 2002-01-31 12:00 A | 128SS+4h | 100% |  | 2002-01-28 13:00 | 2002-01-31 12:00 | 8h |  |  |  | Stuart | 8h | 8h |
| 130 | 1.3.2.4 | Static Analysis | 4h | 2002-02-28 13:00 A | 2002-02-28 17:00 |  | 50% | 2h | 2002-02-28 13:00 | 2002-02-28 17:00 | 4h | 22.12d |  | finish no earlier than 2002-02-28 17:00 | Stuart; Trevor | 6h | 2h |
| 131 | 1.3.2.5 | Update MIPS Emulator | 8h | 2002-03-04 08:00 A | 2002-03-04 17:00 |  | 40% | 4.8h | 2002-03-04 08:00 | 2002-03-04 17:00 | 8h | 21.12d |  | start no earlier than 2002-03-04 08:00 | Stuart | 8h | 3.2h |
| 132 | 1.3.2.6 | Test | 8h | 2002-03-04 08:00 | 2002-03-04 17:00 |  |  |  | 2002-03-04 08:00 | 2002-03-04 17:00 | 8h | 21.12d |  | start no earlier than 2002-03-04 08:00 | Stuart | 8h |  |
| 133 | 1.3.2.7 | Documentation | 8h | 2002-03-07 08:00 | 2002-03-07 17:00 |  | 30% |  | 2002-03-07 08:00 | 2002-03-07 17:00 | 8h | 0d |  | start no earlier than 2002-03-07 08:00 | Stuart; Trevor | 16h |  |
| 134 | 1.3.3 | **Partitioning Prototype** | 8.38d | 2002-02-21 09:00 A | 2002-03-18 12:00 |  | 14% | 7.24d | 2002-02-21 09:00 | 2002-03-18 12:00 | 8.38d | 16.62d |  |  |  | 252h | 12.9h |
| 135 | 1.3.3.1 | **Call Graph of Application** | 3.38d | 2002-02-21 09:00 A | 2002-03-04 12:00 | 71 | 25% | 2.53d | 2002-02-21 09:00 | 2002-03-04 12:00 | 3.38d | 21.12d |  |  |  | 48h | 12h |
| 136 | 1.3.3.1.1 | Encoder | 12h | 2002-02-21 09:00 | 2002-02-25 14:00 |  | 50% |  | 2002-02-21 09:00 | 2002-02-25 14:00 | 12h | 0d |  |  | Hakim | 12h |  |
| 137 | 1.3.3.1.2 | Decoder | 12h | 2002-02-28 08:00 | 2002-03-04 12:00 |  |  |  | 2002-02-28 08:00 | 2002-03-04 12:00 | 12h | 21.12d | 0d | start no earlier than 2002-02-28 08:00 | Jimmy | 12h |  |
| 138 | 1.3.3.1.3 | Encryption | 12h | 2002-02-28 08:00 A | 2002-03-04 12:00 A |  | 100% |  | 2002-02-28 08:00 | 2002-03-04 12:00 | 12h |  |  | start no earlier than 2002-02-28 08:00 | Trevor | 12h | 12h |
| 139 | 1.3.3.1.4 | Decryption | 12h | 2002-02-28 08:00 | 2002-03-04 12:00 |  |  |  | 2002-02-28 08:00 | 2002-03-04 12:00 | 12h | 0d |  | start no earlier than 2002-02-28 08:00 | Hakim | 12h |  |

| ID | WBS | Task | Type | Duration | Start | Finish | Predecessors | Complete | Remaining | Baseline start | Baseline finish | Baseline duration | Total slack | Constraint | Resources | Work | Actual work |
| --- | --- | --- | --- | --- | --- | --- | --- | --- | --- | --- | --- | --- | --- | --- | --- | --- | --- |
| 140 | 1.3.3.2 | **Partition the Application** |  | 1.5d | 2002-03-04 13:00 A | 2002-03-07 17:00 |  | 8% | 1.39d | 2002-03-04 13:00 | 2002-03-07 17:00 | 1.5d | 20.12d |  | Chris | 32h | 0.9h |
| 141 | 1.3.3.2.1 | Encoder |  | 3h | 2002-03-07 08:00 | 2002-03-07 11:00 | 136 |  |  | 2002-03-07 08:00 | 2002-03-07 11:00 | 3h | 20.75d | start no earlier than 2002-03-07 08:00 | Chris | 3h |  |
| 142 | 1.3.3.2.2 | Decoder |  | 3h | 2002-03-04 13:00 | 2002-03-04 16:00 | 137 |  |  | 2002-03-04 13:00 | 2002-03-04 16:00 | 3h | 21.25d | start no earlier than 2002-03-04 08:00 | Chris | 3h |  |
| 143 | 1.3.3.2.3 | Encryption |  | 3h | 2002-03-04 13:00 A | 2002-03-04 16:00 | 138 | 50% | 1.5h | 2002-03-04 13:00 | 2002-03-04 16:00 | 3h | 0d | start no earlier than 2002-03-04 08:00 | Chris | 3h |  |
| 144 | 1.3.3.2.4 | Decryption |  | 3h | 2002-03-07 08:00 | 2002-03-07 11:00 | 139 |  |  | 2002-03-07 08:00 | 2002-03-07 11:00 | 3h | 0d | start no earlier than 2002-03-07 08:00 | Chris | 3h |  |
| 145 | 1.3.3.2.5 | Document |  | 8h | 2002-03-07 08:00 | 2002-03-07 17:00 |  | 30% |  | 2002-03-07 08:00 | 2002-03-07 17:00 | 8h | 0d | start no earlier than 2002-03-07 08:00 | Chris | 8h |  |
| 146 | 1.3.3.3 | **Initial Design** |  | 4.62d | 2002-03-04 16:00 | 2002-03-18 12:00 |  |  |  | 2002-03-04 16:00 | 2002-03-18 12:00 | 4.62d | 0d |  |  | 172h |  |
| 147 | 1.3.3.3.1 | **Encoder** |  | 2.5d | 2002-03-14 08:00 | 2002-03-18 12:00 | 136 |  |  | 2002-03-14 08:00 | 2002-03-18 12:00 | 2.5d | 16.62d |  | Chris; William | 48h |  |
| 148 | 1.3.3.3.1.1 | Communication |  | 4h | 2002-03-14 08:00 | 2002-03-14 12:00 |  |  |  | 2002-03-14 08:00 | 2002-03-14 12:00 | 4h | 18.62d | start no earlier than 2002-03-14 08:00 | Chris | 4h |  |
| 149 | 1.3.3.3.1.2 | Parallelism |  | 4h | 2002-03-18 08:00 | 2002-03-18 12:00 |  |  |  | 2002-03-18 08:00 | 2002-03-18 12:00 | 4h | 16.62d | start no earlier than 2002-03-18 08:00 | William | 4h |  |
| 150 | 1.3.3.3.2 | **Decoder** |  | 1.5d | 2002-03-07 08:00 | 2002-03-11 12:00 | 137 |  |  | 2002-03-07 08:00 | 2002-03-11 12:00 | 1.5d | 19.62d |  | Chris; William | 32h |  |
| 151 | 1.3.3.3.2.1 | Communication |  | 4h | 2002-03-07 08:00 | 2002-03-07 12:00 |  |  |  | 2002-03-07 08:00 | 2002-03-07 12:00 | 4h | 20.62d | start no earlier than 2002-03-07 08:00 | Chris | 4h |  |
| 152 | 1.3.3.3.2.2 | Parallelism |  | 4h | 2002-03-11 08:00 | 2002-03-11 12:00 |  |  |  | 2002-03-11 08:00 | 2002-03-11 12:00 | 4h | 19.62d | start no earlier than 2002-03-11 08:00 | William | 4h |  |
| 153 | 1.3.3.3.3 | **Encryption** |  | 2.62d | 2002-03-04 16:00 | 2002-03-14 12:00 | 143 |  |  | 2002-03-04 16:00 | 2002-03-14 12:00 | 2.62d | 0d |  | Chris; William | 50h |  |
| 154 | 1.3.3.3.3.1 | Communication |  | 4h | 2002-03-04 16:00 | 2002-03-07 11:00 |  | 25% |  | 2002-03-04 16:00 | 2002-03-07 11:00 | 4h | 0d | start no earlier than 2002-02-11 08:00 | Chris | 4h |  |
| 155 | 1.3.3.3.3.2 | Parallelism |  | 4h | 2002-03-14 08:00 | 2002-03-14 12:00 |  |  |  | 2002-03-14 08:00 | 2002-03-14 12:00 | 4h | 0d | start no earlier than 2002-03-14 08:00 | William | 4h |  |
| 156 | 1.3.3.3.4 | **Decryption** |  | 2.12d | 2002-03-07 11:00 | 2002-03-14 12:00 | 144 |  |  | 2002-03-07 11:00 | 2002-03-14 12:00 | 2.12d | 0d |  | Chris; William | 42h |  |
| 157 | 1.3.3.3.4.1 | Communication |  | 4h | 2002-03-07 11:00 | 2002-03-07 16:00 |  | 20% |  | 2002-03-07 11:00 | 2002-03-07 16:00 | 4h | 0d | start no earlier than 2002-03-07 08:00 | Chris | 4h |  |
| 158 | 1.3.3.3.4.2 | Parallelism |  | 4h | 2002-03-14 08:00 | 2002-03-14 12:00 |  |  |  | 2002-03-14 08:00 | 2002-03-14 12:00 | 4h | 0d | start no earlier than 2002-03-14 08:00 | William | 4h |  |
| 159 | 1.3.4 | **Documentation** |  | 4d | 2002-03-11 08:00 A | 2002-03-21 08:00 A |  | 100% |  | 2002-03-11 08:00 | 2002-03-21 08:00 | 4d |  |  |  | 99h | 99h |
| 160 | 1.3.4.1 | Compile documents |  | 8h | 2002-03-11 08:00 A | 2002-03-11 17:00 A |  | 100% |  | 2002-03-11 08:00 | 2002-03-11 17:00 | 8h |  | start no earlier than 2002-03-11 08:00 | Jimmy | 8h | 8h |
| 161 | 1.3.4.2 | Proof Read |  | 5h | 2002-03-14 08:00 A | 2002-03-14 14:00 A |  | 100% |  | 2002-03-14 08:00 | 2002-03-14 14:00 | 5h |  | start no earlier than 2002-03-14 08:00 | Chris; Trevor; Hakim; Jimmy; Sami; Stuart; William | 35h | 35h |
| 162 | 1.3.4.3 | Discuss changes (draft) |  | 2h | 2002-03-15 08:00 A | 2002-03-15 10:00 A |  | 100% |  | 2002-03-15 08:00 | 2002-03-15 10:00 | 2h |  | start no earlier than 2002-03-15 08:00 | William; Trevor; Chris; Sami; Jimmy; Hakim; Stuart | 14h | 14h |
| 163 | 1.3.4.4 | Make Necessary changes(draft) |  | 2h | 2002-03-15 08:00 A | 2002-03-15 10:00 A |  | 100% |  | 2002-03-15 08:00 | 2002-03-15 10:00 | 2h |  | start no earlier than 2002-03-15 08:00 | William; Trevor; Chris; Sami; Jimmy; Hakim; Stuart | 14h | 14h |
| 164 | 1.3.4.5 | Draft version to be Handed in | milestone | 0h | 2002-03-15 08:00 A | 2002-03-15 08:00 A |  | 100% |  | 2002-03-15 08:00 | 2002-03-15 08:00 | 0h |  | start no earlier than 2002-03-15 08:00 |  |  |  |
| 165 | 1.3.4.6 | Discuss changes (final) |  | 2h | 2002-03-18 08:00 A | 2002-03-18 10:00 A |  | 100% |  | 2002-03-18 08:00 | 2002-03-18 10:00 | 2h |  | start no earlier than 2002-03-18 08:00 | William; Trevor; Chris; Sami; Jimmy; Hakim; Stuart | 14h | 14h |
| 166 | 1.3.4.7 | Make Necessary changes (final) |  | 2h | 2002-03-18 08:00 A | 2002-03-18 10:00 A |  | 100% |  | 2002-03-18 08:00 | 2002-03-18 10:00 | 2h |  | start no earlier than 2002-03-18 08:00 | Hakim; William; Trevor; Chris; Sami; Jimmy; Stuart | 14h | 14h |
| 167 | 1.3.4.8 | Hand in The final version | milestone | 0h | 2002-03-21 08:00 A | 2002-03-21 08:00 A |  | 100% |  | 2002-03-21 08:00 | 2002-03-21 08:00 | 0h |  | start no earlier than 2002-03-21 08:00 |  |  |  |
| 168 | 1.3.5 | Plan/stage Review |  | 2h | 2002-03-21 08:00 | 2002-03-21 10:00 |  |  |  | 2002-03-21 08:00 | 2002-03-21 10:00 | 2h | 15.88d | start no earlier than 2002-03-21 08:00 | Chris; Trevor; Hakim; Jimmy; Sami; William; Stuart | 14h |  |
| 169 | 1.3.6 | Change Plan if needed |  | 2h | 2002-03-21 08:00 | 2002-03-21 10:00 |  |  |  | 2002-03-21 08:00 | 2002-03-21 10:00 | 2h | 15.88d | start no earlier than 2002-03-21 08:00 | Hakim | 2h |  |

| ID | WBS | Task | Duration | Start | Finish | Predecessors | Baseline start | Baseline finish | Baseline duration | Total slack | Free slack | Constraint | Resources | Work |
| --- | --- | --- | --- | --- | --- | --- | --- | --- | --- | --- | --- | --- | --- | --- |
| 170 | 1.4 | **Third Stage** | 25d | 2002-01-28 08:00 | 2002-05-09 17:00 |  | 2002-01-28 08:00 | 2002-05-09 17:00 | 25d | 7.12d |  |  |  | 957h |
| 171 | 1.4.1 | **ASIP Prototype** | 2.5d | 2002-01-28 08:00 | 2002-02-04 12:00 |  | 2002-01-28 08:00 | 2002-02-04 12:00 | 2.5d | 29.62d |  |  | Trevor; Stuart | 40h |
| 172 | 1.4.1.1 | Write ASIP Processor | 20h | 2002-01-28 08:00 | 2002-02-04 12:00 |  | 2002-01-28 08:00 | 2002-02-04 12:00 | 20h | 29.62d |  |  |  |  |
| 173 | 1.4.1.2 | Test and Modify | 10h | 2002-01-28 08:00 | 2002-01-31 10:00 |  | 2002-01-28 08:00 | 2002-01-31 10:00 | 10h | 30.88d |  |  |  |  |
| 174 | 1.4.1.3 | Add Parallelism | 8h | 2002-01-28 08:00 | 2002-01-28 17:00 |  | 2002-01-28 08:00 | 2002-01-28 17:00 | 8h | 31.12d |  |  |  |  |
| 175 | 1.4.1.4 | Optimise | 8h | 2002-01-28 08:00 | 2002-01-28 17:00 |  | 2002-01-28 08:00 | 2002-01-28 17:00 | 8h | 31.12d |  |  |  |  |
| 176 | 1.4.1.5 | Interface Implementation | 8h | 2002-01-28 08:00 | 2002-01-28 17:00 |  | 2002-01-28 08:00 | 2002-01-28 17:00 | 8h | 31.12d |  |  |  |  |
| 177 | 1.4.1.6 | Create EDIF | 7h | 2002-01-28 08:00 | 2002-01-28 16:00 |  | 2002-01-28 08:00 | 2002-01-28 16:00 | 7h | 31.25d |  |  |  |  |
| 178 | 1.4.1.7 | System Test | 8h | 2002-01-28 08:00 | 2002-01-28 17:00 |  | 2002-01-28 08:00 | 2002-01-28 17:00 | 8h | 31.12d |  |  |  |  |
| 179 | 1.4.2 | **Partitioning Prototype** | 25d | 2002-01-28 08:00 | 2002-05-09 17:00 |  | 2002-01-28 08:00 | 2002-05-09 17:00 | 25d | 7.12d |  |  |  | 900h |
| 180 | 1.4.2.1 | **Implement Initial design** | 25d | 2002-01-28 08:00 | 2002-05-09 17:00 |  | 2002-01-28 08:00 | 2002-05-09 17:00 | 25d | 7.12d |  |  |  | 800h |
| 181 | 1.4.2.1.1 | **Encoder** | 25d | 2002-01-28 08:00 | 2002-05-09 17:00 |  | 2002-01-28 08:00 | 2002-05-09 17:00 | 25d | 7.12d |  |  | Chris | 200h |
| 182 | 1.4.2.1.1.1 | FPGA side | 20h | 2002-01-28 08:00 | 2002-02-04 12:00 |  | 2002-01-28 08:00 | 2002-02-04 12:00 | 20h | 25.62d | 0d |  |  |  |
| 183 | 1.4.2.1.1.2 | Simulate and change | 12h | 2002-02-04 12:00 | 2002-02-07 17:00 | 182 | 2002-02-04 12:00 | 2002-02-07 17:00 | 12h | 25.62d | 0d |  |  |  |
| 184 | 1.4.2.1.1.3 | Communication | 10h | 2002-02-07 17:00 | 2002-02-14 10:00 | 183 | 2002-02-07 17:00 | 2002-02-14 10:00 | 10h | 25.62d | 18.5d |  |  |  |
| 185 | 1.4.2.1.1.4 | Co-Simulation and change | 10h | 2002-05-06 15:00 | 2002-05-09 17:00 | 184 | 2002-05-06 15:00 | 2002-05-09 17:00 | 10h | 7.12d |  | finish no earlier than 2002-05-09 17:00 |  |  |
| 186 | 1.4.2.1.2 | **Decoder** | 25d | 2002-01-28 08:00 | 2002-05-09 17:00 |  | 2002-01-28 08:00 | 2002-05-09 17:00 | 25d | 7.12d |  |  | Hakim | 200h |
| 187 | 1.4.2.1.2.1 | FPGA side | 20h | 2002-01-28 08:00 | 2002-02-04 12:00 |  | 2002-01-28 08:00 | 2002-02-04 12:00 | 20h | 25.62d | 0d |  |  |  |
| 188 | 1.4.2.1.2.2 | Simulate and change | 12h | 2002-02-04 13:00 | 2002-02-07 17:00 | 187 | 2002-02-04 13:00 | 2002-02-07 17:00 | 12h | 25.62d | 0d |  |  |  |
| 189 | 1.4.2.1.2.3 | Communication | 10h | 2002-02-11 08:00 | 2002-02-14 10:00 | 188 | 2002-02-11 08:00 | 2002-02-14 10:00 | 10h | 25.62d | 18.5d |  |  |  |
| 190 | 1.4.2.1.2.4 | Co-Simulation and change | 10h | 2002-05-06 15:00 | 2002-05-09 17:00 | 189 | 2002-05-06 15:00 | 2002-05-09 17:00 | 10h | 7.12d |  | finish no earlier than 2002-05-09 17:00 |  |  |
| 191 | 1.4.2.1.3 | **Encryption** | 25d | 2002-01-28 08:00 | 2002-05-09 17:00 |  | 2002-01-28 08:00 | 2002-05-09 17:00 | 25d | 7.12d |  |  | William | 200h |
| 192 | 1.4.2.1.3.1 | FPGA side | 20h | 2002-01-28 08:00 | 2002-02-04 12:00 |  | 2002-01-28 08:00 | 2002-02-04 12:00 | 20h | 25.62d | 0d |  |  |  |
| 193 | 1.4.2.1.3.2 | Simulate and change | 12h | 2002-02-04 13:00 | 2002-02-07 17:00 | 192 | 2002-02-04 13:00 | 2002-02-07 17:00 | 12h | 25.62d | 0d |  |  |  |
| 194 | 1.4.2.1.3.3 | Communication | 10h | 2002-02-11 08:00 | 2002-02-14 10:00 | 193 | 2002-02-11 08:00 | 2002-02-14 10:00 | 10h | 25.62d | 18.5d |  |  |  |
| 195 | 1.4.2.1.3.4 | Co-Simulation and change | 10h | 2002-05-06 15:00 | 2002-05-09 17:00 | 194 | 2002-05-06 15:00 | 2002-05-09 17:00 | 10h | 7.12d |  | finish no earlier than 2002-05-09 17:00 |  |  |

| ID | WBS | Task | Duration | Start | Finish | Predecessors | Baseline start | Baseline finish | Baseline duration | Total slack | Free slack | Constraint | Resources | Work |
| --- | --- | --- | --- | --- | --- | --- | --- | --- | --- | --- | --- | --- | --- | --- |
| 196 | 1.4.2.1.4 | **Decryption** | 25d | 2002-01-28 08:00 | 2002-05-09 17:00 |  | 2002-01-28 08:00 | 2002-05-09 17:00 | 25d | 7.12d |  |  | Sami | 200h |
| 197 | 1.4.2.1.4.1 | FPGA side | 20h | 2002-01-28 08:00 | 2002-02-04 12:00 |  | 2002-01-28 08:00 | 2002-02-04 12:00 | 20h | 25.62d | 0d |  |  |  |
| 198 | 1.4.2.1.4.2 | Simulate and change | 12h | 2002-02-04 13:00 | 2002-02-07 17:00 | 197 | 2002-02-04 13:00 | 2002-02-07 17:00 | 12h | 25.62d | 0d |  |  |  |
| 199 | 1.4.2.1.4.3 | Communication | 10h | 2002-02-11 08:00 | 2002-02-14 10:00 | 198 | 2002-02-11 08:00 | 2002-02-14 10:00 | 10h | 25.62d | 18.5d |  |  |  |
| 200 | 1.4.2.1.4.4 | Co-Simulation and change | 10h | 2002-05-06 15:00 | 2002-05-09 17:00 | 199 | 2002-05-06 15:00 | 2002-05-09 17:00 | 10h | 7.12d |  | finish no earlier than 2002-05-09 17:00 |  |  |
| 201 | 1.4.2.1.5 | Integration | 8h | 2002-01-28 08:00 | 2002-01-28 17:00 |  | 2002-01-28 08:00 | 2002-01-28 17:00 | 8h | 31.12d |  |  |  |  |
| 202 | 1.4.2.1.6 | Co-simulation and changes | 12h | 2002-01-28 08:00 | 2002-01-31 12:00 |  | 2002-01-28 08:00 | 2002-01-31 12:00 | 12h | 30.62d |  |  |  |  |
| 203 | 1.4.2.1.7 | Create EDIF | 1h | 2002-01-28 08:00 | 2002-01-28 09:00 |  | 2002-01-28 08:00 | 2002-01-28 09:00 | 1h | 32d |  |  |  |  |
| 204 | 1.4.2.1.8 | System Test | 2h | 2002-01-28 08:00 | 2002-01-28 10:00 |  | 2002-01-28 08:00 | 2002-01-28 10:00 | 2h | 31.88d |  |  |  |  |
| 205 | 1.4.2.2 | **Investigate Alternatives** | 2.5d | 2002-01-28 08:00 | 2002-02-04 12:00 |  | 2002-01-28 08:00 | 2002-02-04 12:00 | 2.5d | 29.62d |  |  |  | 100h |
| 206 | 1.4.2.2.1 | Partitioning | 8h | 2002-01-28 08:00 | 2002-01-28 17:00 |  | 2002-01-28 08:00 | 2002-01-28 17:00 | 8h | 31.12d |  |  |  |  |
| 207 | 1.4.2.2.2 | Parallelism | 20h | 2002-01-28 08:00 | 2002-02-04 12:00 |  | 2002-01-28 08:00 | 2002-02-04 12:00 | 20h | 29.62d |  |  |  |  |
| 208 | 1.4.2.2.3 | Alternative Implementation | 20h | 2002-01-28 08:00 | 2002-02-04 12:00 |  | 2002-01-28 08:00 | 2002-02-04 12:00 | 20h | 29.62d |  |  | Hakim; Chris; Sami; William; Jimmy | 100h |
| 209 | 1.4.3 | **Custom Hardware** | 0.75d | 2002-01-28 08:00 | 2002-01-28 15:00 |  | 2002-01-28 08:00 | 2002-01-28 15:00 | 0.75d | 31.38d |  |  | Trevor | 17h |
| 210 | 1.4.3.1 | Purchase | 1h | 2002-01-28 08:00 | 2002-01-28 09:00 |  | 2002-01-28 08:00 | 2002-01-28 09:00 | 1h | 32d |  |  | Trevor | 1h |
| 211 | 1.4.3.2 | Build | 2h | 2002-01-28 08:00 | 2002-01-28 10:00 |  | 2002-01-28 08:00 | 2002-01-28 10:00 | 2h | 31.88d |  |  | Trevor | 2h |
| 212 | 1.4.3.3 | Test | 2h | 2002-01-28 08:00 | 2002-01-28 10:00 |  | 2002-01-28 08:00 | 2002-01-28 10:00 | 2h | 31.88d |  |  | Trevor | 2h |
| 213 | 1.4.3.4 | Write Driver | 6h | 2002-01-28 08:00 | 2002-01-28 15:00 |  | 2002-01-28 08:00 | 2002-01-28 15:00 | 6h | 31.38d |  |  | Trevor | 6h |
| 214 | 1.5 | **Fourth Stage** | 2d | 2002-01-28 08:00 | 2002-01-31 17:00 |  | 2002-01-28 08:00 | 2002-01-31 17:00 | 2d | 30.12d |  |  |  | 224h |
| 215 | 1.5.1 | Create DLLs | 5h | 2002-01-28 08:00 | 2002-01-28 14:00 |  | 2002-01-28 08:00 | 2002-01-28 14:00 | 5h | 31.5d |  |  | Trevor | 5h |
| 216 | 1.5.2 | Create GUI | 8h | 2002-01-28 08:00 | 2002-01-28 17:00 |  | 2002-01-28 08:00 | 2002-01-28 17:00 | 8h | 31.12d |  |  | Jimmy | 8h |
| 217 | 1.5.3 | Integrate GUI & DLL | 8h | 2002-01-28 08:00 | 2002-01-28 17:00 |  | 2002-01-28 08:00 | 2002-01-28 17:00 | 8h | 31.12d |  |  | Trevor; Jimmy | 16h |
| 218 | 1.5.4 | Test & change | 16h | 2002-01-28 08:00 | 2002-01-31 17:00 |  | 2002-01-28 08:00 | 2002-01-31 17:00 | 16h | 30.12d |  |  | Trevor; Jimmy | 32h |
| 219 | 1.5.5 | **Documentation** | 2d | 2002-01-28 08:00 | 2002-01-31 17:00 |  | 2002-01-28 08:00 | 2002-01-31 17:00 | 2d | 30.12d |  |  |  | 86h |
| 220 | 1.5.5.1 | Compile | 16h | 2002-01-28 08:00 | 2002-01-31 17:00 |  | 2002-01-28 08:00 | 2002-01-31 17:00 | 16h | 30.12d |  |  | Hakim | 16h |
| 221 | 1.5.5.2 | Proof Read | 5h | 2002-01-28 08:00 | 2002-01-28 14:00 |  | 2002-01-28 08:00 | 2002-01-28 14:00 | 5h | 31.5d |  |  | Stuart; William; Sami; Jimmy; Trevor; Chris; Hakim | 35h |
| 222 | 1.5.5.3 | Edit | 5h | 2002-01-28 08:00 | 2002-01-28 14:00 |  | 2002-01-28 08:00 | 2002-01-28 14:00 | 5h | 31.5d |  |  | Stuart; William; Sami; Jimmy; Trevor; Chris; Hakim | 35h |

| ID | WBS | Task | Type | Duration | Start | Finish | Baseline start | Baseline finish | Baseline duration | Total slack | Resources | Work |
| --- | --- | --- | --- | --- | --- | --- | --- | --- | --- | --- | --- | --- |
| 223 | 1.5.6 | **Plan for Demo & Pres.** |  | 0.62d | 2002-01-28 08:00 | 2002-01-28 14:00 | 2002-01-28 08:00 | 2002-01-28 14:00 | 0.62d | 31.5d |  | 70h |
| 224 | 1.5.6.1 | Plan & Prepare |  | 5h | 2002-01-28 08:00 | 2002-01-28 14:00 | 2002-01-28 08:00 | 2002-01-28 14:00 | 5h | 31.5d | Chris; Trevor; Jimmy; Sami; William; Stuart; Hakim | 35h |
| 225 | 1.5.6.2 | Practice |  | 5h | 2002-01-28 08:00 | 2002-01-28 14:00 | 2002-01-28 08:00 | 2002-01-28 14:00 | 5h | 31.5d | Chris; Trevor; Jimmy; Sami; William; Stuart; Hakim | 35h |
| 226 | 1.5.7 | **Tidy up the project** |  | 0.12d | 2002-01-28 08:00 | 2002-01-28 09:00 | 2002-01-28 08:00 | 2002-01-28 09:00 | 0.12d | 32d |  | 7h |
| 227 | 1.5.7.1 | Present & Demonstrate the project |  | 1h | 2002-01-28 08:00 | 2002-01-28 09:00 | 2002-01-28 08:00 | 2002-01-28 09:00 | 1h | 32d | Chris; Trevor; Jimmy; Sami; William; Stuart; Hakim | 7h |
| 228 | 1.5.7.2 | Hand in 2 Copies Of the report | milestone | 0h | 2002-01-28 08:00 | 2002-01-28 08:00 | 2002-01-28 08:00 | 2002-01-28 08:00 | 0h | 32.12d | Hakim |  |
